# Proyecto de Ejemplo 1

Schedule from MS Project, 2024-10-01 to 2025-11-28, 6 hours a day.

## Calendars

- Estándar: Mon-Fri 09:00-13:00, 15:00-19:00; Sat-Sun off.
- Calendario L-Mi-V: Mon 08:00-12:00, 13:00-15:00; Tue off; Wed 08:00-12:00, 13:00-15:00; Thu off; Fri 08:00-12:00, 13:00-15:00; Sat-Sun off. Exceptions (off unless hours are given): 2025-01-01 (Año Nuevo), 2025-01-06 (Dia de Reyes), 2025-01-21 (Virgen De La Altagracia), 2025-02-27 (Independencia Nacional), 2025-04-17 (Jueves Santos), 2025-04-18 (Viernes santos), 2025-05-01 (Dia Del Trabajador), 2025-06-19 (Corpus Christi), 2025-09-24 (Dia de La Mercedes), 2025-11-10 (Dia de La Constitucion).
- Calendario Ma y J: Mon off; Tue 08:00-12:00, 13:00-15:00; Wed off; Thu 08:00-12:00, 13:00-15:00; Fri-Sun off. Exceptions (off unless hours are given): 2025-01-01 (Año Nuevo), 2025-01-06 (Dia de Reyes), 2025-01-21 (Virgen De La Altagracia), 2025-02-27 (Independencia Nacional), 2025-04-17 (Jueves Santos), 2025-04-18 (Viernes Santos), 2025-05-01 (Dia Del Trabajador), 2025-06-19 (Corpus Christi), 2025-08-16 (Dia de la Restauracion), 2025-09-24 (Dia de Las Mercedes), 2025-11-10 (Dia de la Constitucion).

## Resources

| Resource |
| --- |
| Hoyero 1 |
| Hoyero 2 |
| Hoyero 3 |
| Hoyero 4 |
| Hoyero 5 |
| Hoyero 6 |
| Hoyero 7 |
| Hoyero 8 |
| Hoyero 9 |
| Hoyero 10 |
| Grúa 1 |
| Grúa 2 |
| Grúa 3 |
| Grúa 4 |
| Grúa 5 |
| Canasto 1 |
| Canasto 2 |
| Canasto 3 |
| Canasto 4 |
| Canasto 5 |
| Canasto 6 |
| Canasto 7 |
| Canasto 8 |
| Canasto 9 |
| Canasto 10 |
| Brigada de Normalización 1 |
| Brigada de Normalización 2 |
| Brigada de Normalización 3 |
| Brigada de Normalización 4 |
| Brigada de Normalización 5 |
| Supervisor 1 |
| Supervisor 2 |
| Supervisor 3 |
| Supervisor 4 |
| Supervisor 5 |
| Supervisor 6 |
| Supervisor 7 |
| Supervisor 8 |
| Supervisor 9 |
| Supervisor 10 |
| Capataz 1 |
| Capataz 2 |
| Capataz 3 |
| Capataz 4 |
| Capataz 5 |
| Capataz 6 |
| Capataz 7 |
| Capataz 8 |
| Capataz 9 |
| Capataz 10 |
| Brigada de Poda 1 |
| Brigada de Poda 2 |
| Brigada de Poda 3 |
| Brigada de Poda 4 |
| Brigada de Poda 5 |
| Brigada de Poda 6 |
| Brigada de Poda 7 |
| Brigada de Poda 8 |
| Brigada de Poda 9 |
| Brigada de Poda 10 |
| Brigada Ligera 1 |
| Brigada Ligera 2 |
| Brigada Ligera 3 |
| Brigada Ligera 4 |
| Brigada Ligera 5 |
| Brigada Ligera 6 |
| Brigada Ligera 7 |
| Brigada Ligera 8 |
| Brigada Ligera 9 |
| Brigada Ligera 10 |
| Hoyero 1 A |
| Hoyero 2 B |
| Hoyero 3 C |
| Hoyero 4 D |
| Hoyero 5 E |
| Hoyero 6 F |
| Hoyero 7 G |
| Hoyero 8 H |
| Hoyero 9 I |
| Hoyero 10 J |
| Grúa 1 A |
| Grúa 2 B |
| Grúa 3 C |
| Grúa 4 D |
| Grúa 5 E |
| Canasto 1 A |
| Canasto 2 B |
| Canasto 3 C |
| Canasto 4 D |
| Canasto 5 E |
| Canasto 6 F |
| Canasto 7 G |
| Canasto 8 H |
| Canasto 9 I |
| Canasto 10 J |
| Brigada de Normalización 1 A |
| Brigada de Normalización 2 B |
| Brigada de Normalización 3 C |
| Brigada de Normalización 4 D |
| Brigada de Normalización 5 E |
| Brigada de Normalización 6 F |
| Brigada de Normalización 7 G |
| Brigada de Normalización 8 H |
| Brigada de Normalización 9 I |
| Brigada de Normalización 10 J |
| Supervisor 1 A |
| Supervisor 2 B |
| Supervisor 3 C |
| Supervisor 4 D |
| Supervisor 5 E |
| Supervisor 6 F |
| Supervisor 7 G |
| Supervisor 8 H |
| Supervisor 9 I |
| Supervisor 10 J |
| Capataz 1 A |
| Capataz 2 B |
| Capataz 3 C |
| Capataz 4 D |
| Capataz 5 E |
| Capataz 6 F |
| Capataz 7 G |
| Capataz 8 H |
| Capataz 9 I |
| Capataz 10 J |
| Brigada de Poda 1 A |
| Brigada de Poda 2 B |
| Brigada de Poda 3 C |
| Brigada de Poda 4 D |
| Brigada de Poda 5 E |
| Brigada de Poda 6 F |
| Brigada de Poda 7 G |
| Brigada de Poda 8 H |
| Brigada de Poda 9 I |
| Brigada de Poda 10 J |
| Brigada Ligera 1 A |
| Brigada Ligera 2 B |
| Brigada Ligera 3 C |
| Brigada Ligera 4 D |
| Brigada Ligera 5 E |
| Brigada Ligera 6 F |
| Brigada Ligera 7 G |
| Brigada Ligera 8 H |
| Brigada Ligera 9 I |
| Brigada Ligera 10 J |

## Schedule

| ID | WBS | Task | Duration | Start | Finish | Predecessors | Total slack | Free slack | Constraint | Calendar | Resources | Work | Días Calendario | Cantidad |
| --- | --- | --- | --- | --- | --- | --- | --- | --- | --- | --- | --- | --- | --- | --- |
| 1 | 1 | **Proyecto Lote 2 PEND103HOG Licey Hoya Grande** | 404.67d | 2024-10-01 | 2025-11-28 |  | 0d |  |  | Estándar |  | 9456h | 424días |  |
| 2 | 1.1 | **Preparativos previos Obras** | 44d | 2024-10-01 | 2024-11-14 |  | 85.33d |  |  | Estándar |  |  | 45días |  |
| 3 | 1.1.1 | Reuniones con Contratista | 5d | 2024-10-01 | 2024-10-04 |  | 268d | 0d | start no earlier than 2024-10-01 | Estándar |  |  | 4días |  |
| 4 | 1.1.2 | Revisiones adicionales de Ingenieria-Replanteo | 30d | 2024-10-07 | 2024-11-06 | 3FS+1d | 268d | 0d |  | Estándar |  |  | 31días |  |
| 5 | 1.1.3 | Firma Minuta | 7d | 2024-11-07 | 2024-11-14 | 4FS+1d | 268d | 46.67d |  | Estándar |  |  | 8días |  |
| 6 | 1.1.4 | Obtension Recursos Contratista | 30d | 2024-10-07 | 2024-11-06 |  | 417.33d |  | start no earlier than 2024-10-07 | Estándar |  |  | 31días |  |
| 7 | 1.1.5 | Gestion de Materiales y Revision contra Fichas Tecnicas | 21d | 2024-10-07 | 2024-10-29 | 3FS+1d | 425.67d |  |  | Estándar |  |  | 23días |  |
| 8 | 1.2 | **Suministro Materiales** | 119d | 2024-10-17 | 2025-02-19 |  | 269.67d |  |  | Estándar |  |  | 126días |  |
| 9 | 1.2.1 | Suministro Postes | 90d | 2024-10-17 | 2025-01-20 | 4SS+10d | 317.67d | 0d |  | Estándar |  |  | 96días |  |
| 10 | 1.2.2 | Suministro Armados | 90d | 2024-10-31 | 2025-02-03 | 9SS+14d | 317.67d | 0d |  | Estándar |  |  | 96días |  |
| 11 | 1.2.3 | Suministro Tendido (Cables) | 90d | 2024-11-15 | 2025-02-19 | 10SS+15d | 317.67d | 0d |  | Estándar |  |  | 97días |  |
| 12 | 1.2.4 | Suministro Transformadores | 90d | 2024-11-15 | 2025-02-19 | 11SS | 317.67d |  |  | Estándar |  |  | 97días |  |
| 13 | 1.2.5 | Suministro Equipos Proteccion | 90d | 2024-11-15 | 2025-02-19 | 11SS | 317.67d |  |  | Estándar |  |  | 97días |  |
| 14 | 1.2.6 | Suminiostro Alumbrado Publico | 90d | 2024-11-15 | 2025-02-19 | 11SS | 317.67d |  |  | Estándar |  |  | 97días |  |
| 15 | 1.2.7 | Suministro Acometida y medidores | 90d | 2024-11-15 | 2025-02-19 | 11SS | 317.67d |  |  | Estándar |  |  | 97días |  |
| 16 | 1.3 | **Ejecucion de Obras** | 157d | 2024-11-18 | 2025-11-28 |  | 0d |  |  |  |  | 9456h | 376días |  |
| 17 | 1.3.1 | **Poligono 1** | 59d | 2024-11-18 | 2025-04-07 |  | 98d |  |  |  |  | 2064h | 141días |  |
| 18 | 1.3.1.1 | Excavaciones | 9d | 2024-11-18 | 2024-12-06 | 5FS+1d | 118d | 0d |  |  | Hoyero 2; Hoyero 3; Hoyero 4; Hoyero 5; Hoyero 6; Hoyero 7; Hoyero 8; Hoyero 9; Hoyero 10; Hoyero 1 | 540h | 19días | 369 |
| 19 | 1.3.1.2 | Izado de postes | 9d | 2024-11-18 | 2024-12-06 | 18SS | 118d | 0d |  |  | Grúa 2; Grúa 3; Grúa 1 | 162h | 19días | 186 |
| 20 | 1.3.1.3 | Cimentaciones | 1d | 2025-01-27 | 2025-01-27 | 19FF | 148d |  |  |  | Brigada Ligera 1 | 6h | 1días |  |
| 21 | 1.3.1.4 | Retenidas | 10d | 2024-11-22 | 2024-12-27 | 19SS+2d | 159d |  |  |  | Canasto 1; Brigada Ligera 3; Brigada Ligera 2 | 180h | 36días | 183 |
| 22 | 1.3.1.5 | Armados MT y BT | 15d | 2024-11-20 | 2024-12-23 | 19SS+1d | 118d | 0d |  |  | Canasto 2; Canasto 3; Canasto 4 | 270h | 34días | 371 |
| 23 | 1.3.1.6 | Tendido de Conductor MT y BT | 15d | 2024-12-25 | 2025-01-31 | 22 | 118d | 0d |  |  | Canasto 2; Canasto 3; Canasto 4 | 270h | 38días | 15,337 |
| 24 | 1.3.1.7 | Puesta a Tierra | 5d | 2024-12-30 | 2025-01-13 | 23SS+2d | 154d |  |  |  | Canasto 5; Canasto 1 | 60h | 15días | 102 |
| 25 | 1.3.1.8 | Conexiones y Jumper | 7d | 2025-01-22 | 2025-02-05 | 23SS+10d | 144d |  |  |  | Canasto 5; Canasto 1 | 84h | 15días | 131 |
| 26 | 1.3.1.9 | Transformadores | 3d | 2025-02-03 | 2025-02-07 | 23 | 118d | 0d |  |  | Grúa 1; Grúa 2; Canasto 2; Canasto 3 | 72h | 5días | 20 |
| 27 | 1.3.1.10 | Alumbrado Público | 7d | 2025-02-10 | 2025-02-24 | 26 | 136d |  |  |  | Canasto 1; Canasto 2 | 84h | 15días | 201 |
| 28 | 1.3.1.11 | Etiquetas CT | 1d | 2025-02-10 | 2025-02-10 | 26 | 118d | 0d |  |  | Canasto 4; Canasto 3 | 12h | 1días | 22 |
| 29 | 1.3.1.12 | Totalizadores | 4d | 2025-02-12 | 2025-02-19 | 28 | 138d |  |  |  | Canasto 4; Canasto 5 | 48h | 8días | 22 |
| 30 | 1.3.1.13 | Acometida | 13d | 2025-02-19 | 2025-03-19 | 28FS+3d | 118d | 0d |  |  | Brigada de Normalización 2; Brigada de Normalización 1 | 156h | 29días | 500 |
| 31 | 1.3.1.14 | Remoción | 5d | 2025-03-28 | 2025-04-07 | 30FS+3d | 118d |  |  |  | Grúa 1; Grúa 2; Canasto 6; Canasto 7 | 120h | 11días | 465 |

Notes:
- 19: No se le asigna canasto, pero requiere uno para apertura y cierre de seccionador
- 23: Con una grua es suficiente para darle apoyo a los canastos.

| ID | WBS | Task | Type | Duration | Start | Finish | Predecessors | Total slack | Free slack | Constraint | Calendar | Resources | Work | Días Calendario | Cantidad |
| --- | --- | --- | --- | --- | --- | --- | --- | --- | --- | --- | --- | --- | --- | --- | --- |
| 33 | 1.3.2 | **Poligono 2** |  | 78d | 2024-11-21 | 2025-09-04 |  | 24d |  |  | Calendario Ma y J |  | 2988h | 288días |  |
| 34 | 1.3.2.1 | Excavaciones |  | 13d | 2024-11-21 | 2025-01-02 | 5FS+1d | 35d | 0d |  | Calendario Ma y J | Hoyero 2 B; Hoyero 3 C; Hoyero 4 D; Hoyero 5 E; Hoyero 6 F; Hoyero 7 G; Hoyero 8 H; Hoyero 9 I; Hoyero 10 J; Hoyero 1 A | 780h | 43días | 531 |
| 35 | 1.3.2.2 | Izado de postes |  | 14d | 2024-11-21 | 2025-01-07 | 34SS | 35d | 0d |  | Calendario Ma y J | Grúa 2 B; Grúa 3 C; Grúa 1 A | 252h | 48días | 284 |
| 36 | 1.3.2.3 | Cimentaciones | milestone | 0d | 2025-01-07 | 2025-01-07 | 35 | 99d |  |  | Calendario Ma y J |  |  | 0 días |  |
| 37 | 1.3.2.4 | Retenidas |  | 8d | 2024-12-03 | 2024-12-26 | 35SS+3d | 102d |  |  | Calendario Ma y J | Canasto 1 A; Brigada Ligera 1 A; Brigada Ligera 2 B; Brigada Ligera 3 C | 192h | 24días | 247 |
| 38 | 1.3.2.5 | Armados MT y BT |  | 17d | 2024-12-03 | 2025-01-30 | 35SS+3d | 35d | 0d |  | Calendario Ma y J | Canasto 2 B; Canasto 3 C; Canasto 4 D; Canasto 5 E | 408h | 59días | 531 |
| 39 | 1.3.2.6 | Tendido de Conductor MT y BT |  | 13d | 2025-02-04 | 2025-03-20 | 38 | 35d | 0d |  | Calendario Ma y J | Canasto 2 B; Canasto 3 C; Canasto 4 D; Canasto 5 E; Canasto 1 A | 390h | 45días | 22,600 |
| 40 | 1.3.2.7 | Puesta a Tierra |  | 5d | 2025-03-25 | 2025-04-08 | 39 | 35d | 0d |  | Calendario Ma y J | Canasto 1 A; Canasto 2 B; Canasto 3 C | 90h | 15días | 147 |
| 41 | 1.3.2.8 | Conexiones y Jumper |  | 8d | 2025-03-25 | 2025-04-22 | 39 | 62d | 0d |  | Calendario Ma y J | Canasto 4 D; Canasto 5 E | 96h | 29días | 150 |
| 42 | 1.3.2.9 | Transformadores |  | 3d | 2025-04-10 | 2025-04-22 | 40 | 35d | 0d |  | Calendario Ma y J | Grúa 1 A; Grúa 2 B; Grúa 3 C; Canasto 1 A; Canasto 2 B; Canasto 3 C | 108h | 13días | 30 |
| 43 | 1.3.2.10 | Alumbrado Público |  | 10d | 2025-04-24 | 2025-05-29 | 41 | 62d |  |  | Calendario Ma y J | Canasto 4 D; Canasto 5 E | 120h | 36días | 298 |
| 44 | 1.3.2.11 | Etiquetas CT |  | 1d | 2025-04-24 | 2025-04-24 | 42 | 35d | 0d |  | Calendario Ma y J | Canasto 1 A; Canasto 2 B | 12h | 1días | 34 |
| 45 | 1.3.2.12 | Totalizadores |  | 4d | 2025-04-29 | 2025-05-13 | 44 | 35d | 0d |  | Calendario Ma y J | Canasto 2 B; Canasto 1 A; Canasto 3 C | 72h | 15días | 34 |
| 46 | 1.3.2.13 | Acometida |  | 25d | 2025-05-08 | 2025-08-05 | 45SS+2d | 35d | 0d |  | Calendario Ma y J | Brigada de Normalización 2 B; Brigada de Normalización 1 A | 300h | 90días | 980 |
| 47 | 1.3.2.14 | Remoción |  | 7d | 2025-08-14 | 2025-09-04 | 46FS+2d | 35d |  |  | Calendario Ma y J | Grúa 1 A; Canasto 1 A; Canasto 2 B; Grúa 2 B | 168h | 22días | 710 |
| 49 | 1.3.3 | **Poligono 3** |  | 123d | 2025-02-10 | 2025-11-28 |  | 0d |  |  |  |  | 4404h | 292días |  |
| 50 | 1.3.3.1 | Excavaciones |  | 20d | 2025-02-10 | 2025-03-26 |  | 0d |  | start no earlier than 2025-02-10 |  | Hoyero 4; Hoyero 5; Hoyero 6; Hoyero 7; Hoyero 8; Hoyero 9; Hoyero 10; Hoyero 1; Hoyero 2; Hoyero 3 | 1200h | 45días | 807 |
| 51 | 1.3.3.2 | Izado de postes |  | 19d | 2025-02-10 | 2025-03-24 | 50SS | 0d |  |  |  | Grúa 1; Grúa 2; Grúa 3 | 342h | 43días | 392 |
| 52 | 1.3.3.3 | Cimentaciones |  | 3d | 2025-03-19 | 2025-03-24 | 51FF | 104d |  |  |  | Brigada Ligera 1 | 18h | 6días | 15 |
| 53 | 1.3.3.4 | Retenidas |  | 21d | 2025-02-14 | 2025-04-02 | 51SS+2d | 0d |  |  |  | Brigada Ligera 3; Brigada Ligera 2; Canasto 3 | 378h | 48días | 415 |
| 54 | 1.3.3.5 | Armados MT y BT |  | 20d | 2025-04-04 | 2025-05-21 | 53 | 0d |  |  |  | Canasto 5; Canasto 1; Canasto 2; Canasto 3; Canasto 4 | 600h | 48días | 769 |
| 55 | 1.3.3.6 | Tendido de Conductor MT y BT |  | 18d | 2025-05-23 | 2025-07-02 | 54 | 0d |  |  |  | Canasto 1; Canasto 2; Canasto 3; Canasto 4; Canasto 5 | 540h | 41días | 32,204 |
| 56 | 1.3.3.7 | Puesta a Tierra |  | 4d | 2025-07-04 | 2025-07-11 | 55 | 0d |  |  |  | Canasto 2; Canasto 3; Canasto 4; Canasto 1; Canasto 5 | 120h | 8días | 207 |
| 57 | 1.3.3.8 | Conexiones y Jumper |  | 5d | 2025-07-14 | 2025-07-23 | 56 | 0d |  |  |  | Canasto 5; Canasto 1; Canasto 2; Canasto 3; Canasto 4 | 150h | 10días | 253 |
| 58 | 1.3.3.9 | Transformadores |  | 3d | 2025-07-25 | 2025-07-30 | 57 | 0d |  |  |  | Canasto 3; Canasto 4; Canasto 5; Grúa 4; Grúa 5; Grúa 3; Grúa 1; Grúa 2; Canasto 1; Canasto 2 | 180h | 6días | 38 |
| 59 | 1.3.3.10 | Alumbrado Público |  | 5d | 2025-08-01 | 2025-08-11 | 58 | 0d |  |  |  | Canasto 5; Canasto 4; Canasto 1; Canasto 2; Canasto 3 | 150h | 11días | 411 |
| 60 | 1.3.3.11 | Etiquetas CT |  | 1d | 2025-08-13 | 2025-08-13 | 59 | 44d |  |  |  | Canasto 2; Canasto 1 | 12h | 1días | 40 |
| 61 | 1.3.3.12 | Totalizadores |  | 7d | 2025-08-13 | 2025-08-27 | 59 | 0d |  |  |  | Canasto 3; Canasto 4; Canasto 5 | 126h | 15días | 40 |
| 62 | 1.3.3.13 | Acometida |  | 29d | 2025-08-20 | 2025-10-27 | 61SS+3d | 0d |  |  |  | Brigada de Normalización 2; Brigada de Normalización 1 | 348h | 69días | 1,175 |
| 63 | 1.3.3.14 | Remoción |  | 10d | 2025-11-05 | 2025-11-28 | 62FS+3d | 0d |  |  |  | Canasto 2; Canasto 1; Grúa 1; Grúa 2 | 240h | 24días | 980 |

Notes:
- 35: No se le asigna canasto, pero requiere uno para apertura y cierre de seccionador
- 39: Con una grua es suficiente para darle apoyo a los canastos.
- 51: No se le asigna canasto, pero requiere uno para apertura y cierre de seccionador
- 55: Con una grua es suficiente para darle apoyo a los canastos.
